# Puerto_Caldera_IFC_INCOP v11

Schedule from MS Project, 2023-05-22 to 2026-08-11, A marks actual dates.

## Calendars

- Standard: Mon-Fri 08:00-12:00, 13:00-17:00; Sat-Sun off. Exceptions (off unless hours are given): 2025-12-24 to 2025-12-25 (Festivos), 2025-12-29 to 2026-01-02 (Festivos año nuevo), 2026-01-19 to 2026-01-29 (Espacio sub).

## Resources

| Resource |
| --- |
| Proponentes |
| IFC |
| INCOP |
| MIDEPLAN |
| Contraloría |
| Comite Evaluador |
| Adjudicatario |
| MOPT |
| Hacienda |
| Presidencia CR |
| Consultor |
| Consultor técnico |
| Concesionarios actuales |
| SETENA |
| Firma de auditoría |
| Nuevo concesionario |
| ARESEP |

## Schedule

| ID | WBS | Task | Duration | Start | Finish | Predecessors | Complete | Remaining | Total slack | Constraint | Resources | Work | Actual work |
| --- | --- | --- | --- | --- | --- | --- | --- | --- | --- | --- | --- | --- | --- |
| 1 | 1 | Inicio | 1d | 2023-05-31 | 2023-05-31 |  |  |  | 818d |  |  |  |  |
| 2 | 2 | Refrendo del Contrato de Servicios de Asesoría Transaccional por la CGR | 1d | 2023-05-22 A | 2023-05-22 A |  | 100% |  |  | must start on 2023-05-22 |  |  |  |
| 3 | 3 | **Contratación Consultores de la CFI** | 20d | 2023-05-31 A | 2023-06-27 A |  | 100% |  |  |  |  |  |  |
| 4 | 3.1 | Técnico | 8d | 2023-05-31 A | 2023-06-09 A |  | 100% |  |  |  |  |  |  |
| 5 | 3.2 | Ambiental y Social | 11d | 2023-05-31 A | 2023-06-14 A |  | 100% |  |  |  |  |  |  |
| 6 | 3.3 | Legal | 20d | 2023-05-31 A | 2023-06-27 A |  | 100% |  |  |  |  |  |  |
| 7 | 3.4 | Comunicación | 20d | 2023-05-31 A | 2023-06-27 A |  | 100% |  |  |  |  |  |  |
| 8 | 3.5 | Costo Beneficio, Riesgos y Valor por dinero | 20d | 2023-05-31 A | 2023-06-27 A |  | 100% |  |  |  |  |  |  |
| 9 | 4 | **Fase 1 - Preinversión, Inversión y Cartel** | 362d | 2023-06-12 A | 2024-10-29 |  | 96% | 15.37d | 449d |  |  | 1488h | 1488h |
| 10 | 4.1 | Reunión inicial: Plan de Trabajo | 3d | 2023-06-14 A | 2023-06-16 A |  | 100% |  |  | start no earlier than 2023-06-14 |  |  |  |
| 11 | 4.2 | Consultas comité para socialización del Proyecto (MIDEPLAN, MOPT, ARESEP, SETENA) | 3d | 2023-06-14 A | 2023-06-16 A |  | 100% |  |  | start no earlier than 2023-06-14 |  |  |  |
| 12 | 4.3 | Entrega del Plan de Trabajo (honorario 1) | 1d | 2023-06-14 A | 2023-06-14 A |  | 100% |  |  | start no earlier than 2023-06-14 | IFC | 8h | 8h |
| 13 | 4.4 | Debida diligencia Legal | 97d | 2023-06-28 A | 2023-11-09 A | 6 | 100% |  |  | start no earlier than 2023-06-20 |  |  |  |
| 14 | 4.5 | Debida Diligencia Técnica, de Mercado y Análisis Tarifario | 109d | 2023-06-12 A | 2023-11-09 A | 4 | 100% |  |  | start no earlier than 2023-06-01 |  |  |  |
| 15 | 4.6 | Debida Diligencia Socio-Ambiental | 106d | 2023-06-15 A | 2023-11-09 A | 5 | 100% |  |  | start no earlier than 2023-06-06 |  |  |  |
| 16 | 4.7 | Debida Diligencia Financiera | 97d | 2023-06-19 A | 2023-10-31 A | 10 | 100% |  |  | start no earlier than 2023-06-19 |  |  |  |
| 17 | 4.8 | Sondeo de mercado | 10d | 2023-10-02 A | 2023-10-13 A |  | 100% |  |  | finish no earlier than 2023-10-13 |  |  |  |
| 18 | 4.9 | Plan de Comunicaciones | 98d | 2023-06-28 A | 2023-11-10 A | 7 | 100% |  |  | finish no earlier than 2023-10-31 |  |  |  |
| 19 | 4.10 | Entrega de los Estudios de Debida Diligencia Legal (Honorario 2 ) | 1d | 2023-11-10 A | 2023-11-10 A | 13 | 100% |  |  |  | IFC | 8h | 8h |
| 20 | 4.11 | Entrega de los estudios de Debida Diligencia Técnica y Socio-Ambiental (Honorario 3) | 1d | 2023-11-10 A | 2023-11-10 A | 14 | 100% |  |  |  | IFC | 8h | 8h |
| 21 | 4.12 | Preparación del Informe de Prefactibilidad | 13d | 2023-11-13 A | 2023-11-29 A | 20 | 100% |  |  | start no earlier than 2023-10-02 |  |  |  |
| 22 | 4.13 | Entrega del Informe de Prefactibilidad (Honorario 4) | 1d | 2023-11-30 A | 2023-11-30 A | 21 | 100% |  |  |  | IFC | 8h | 8h |
| 23 | 4.14 | Aprobación de INCOP del Informe de Prefactibilidad | 19d | 2024-01-04 A | 2024-01-30 A | 22 | 100% |  |  | finish no earlier than 2024-01-30 | INCOP | 152h | 152h |
| 24 | 4.15 | Aprobación de la Secretaría de Planeación Sectorial del MOPT y de MIDEPLAN del Informe de Prefactibilidad | 65d | 2024-01-31 A | 2024-04-30 A | 23 | 100% |  |  | finish no earlier than 2024-04-30 | MIDEPLAN | 520h | 520h |
| 25 | 4.16 | Preparación del Informe de Factibilidad | 58d | 2024-05-01 A | 2024-07-19 A | 24 | 100% |  |  |  |  |  |  |
| 26 | 4.17 | Entrega del Informe de Factibilidad (Honorario 5) | 1d | 2024-07-22 A | 2024-07-22 A | 25 | 100% |  |  |  | IFC | 8h | 8h |
| 27 | 4.18 | Aprobación de INCOP del Informe de Factibilidad | 32d | 2024-07-23 A | 2024-09-04 A | 26 | 100% |  |  |  | INCOP | 256h | 256h |
| 28 | 4.19 | Aprobación de la Secretaría de Planeación Sectorial del MOPT y de MIDEPLAN del Informe de Factibilidad | 3d | 2024-09-05 A | 2024-09-09 A | 27 | 100% |  |  |  | MIDEPLAN | 24h | 24h |

| ID | WBS | Task | Duration | Start | Finish | Predecessors | Complete | Remaining | Total slack | Constraint | Resources | Work | Actual work |
| --- | --- | --- | --- | --- | --- | --- | --- | --- | --- | --- | --- | --- | --- |
| 29 | 4.20 | **Proceso de Requerimientos Comision Evaluadora y Criterios de Admisibilidad** | 63d | 2024-01-31 A | 2024-04-26 |  | 59% | 25.54d | 581d |  |  | 32h | 32h |
| 30 | 4.20.1 | Redacción de Requerimientos de Legales, Técnicos y Financieros para Expresiones de Interés | 17d | 2024-01-31 A | 2024-02-22 A | 23 | 100% |  |  |  |  |  |  |
| 31 | 4.20.2 | Entrega de Requerimientos de Legales, Técnicos y Financieros (Honorario 6) | 1d | 2024-02-23 A | 2024-02-23 A | 30 | 100% |  |  |  | IFC | 8h | 8h |
| 32 | 4.20.3 | Aprobación de INCOP Criterios de Admisibilidad | 2d | 2024-02-26 A | 2024-02-27 A | 31 | 100% |  |  |  | INCOP | 16h | 16h |
| 33 | 4.20.4 | Entrega de Requerimientos de Comision Evaluadora | 1d | 2024-02-23 A | 2024-02-23 A | 30 | 100% |  |  |  | INCOP | 8h | 8h |
| 34 | 4.20.5 | Formación Comité Evaluador | 45d | 2024-02-26 | 2024-04-26 | 31 |  |  | 581d |  |  |  |  |
| 35 | 4.20.6 | Sondeo de Mercado con espectro de potenciales interesados | 45d | 2024-02-26 A | 2024-04-26 A | 31 | 100% |  |  |  |  |  |  |
| 36 | 4.21 | **Cartel de Licitación y Contrato de Concesión** | 195d | 2024-01-31 A | 2024-10-29 A |  | 100% |  |  |  |  | 464h | 464h |
| 37 | 4.21.1 | Redacción Cartel de Licitación y Contrato de Concesión | 136d | 2024-01-31 A | 2024-08-07 A | 23 | 100% |  |  |  |  |  |  |
| 38 | 4.21.2 | Entrega Cartel de Licitación y Contrato de Concesión (Honorario 7) | 1d | 2024-08-08 A | 2024-08-08 A | 37 | 100% |  |  |  | IFC | 8h | 8h |
| 39 | 4.21.3 | **Proceso de aprobacion para la publicación del Cartel de Licitación** | 57d | 2024-08-09 A | 2024-10-28 A | 38 | 100% |  |  |  |  | 456h | 456h |
| 40 | 4.21.3.1 | Aprobación por la junta directiva de INCOP | 57d | 2024-08-09 A | 2024-10-28 A | 38 | 100% |  |  |  | INCOP | 456h | 456h |
| 41 | 4.21.3.2 | Aprobación de Ministerio de Ambiente sobre requerimientos de estudios ambientales en el Cartel | 1d | 2024-09-06 A | 2024-09-06 A | 40 | 100% |  |  |  |  |  |  |
| 42 | 4.21.3.3 | Aprobación de ARESEP de la estructura tarifaria y los parámetros de ajuste | 10d | 2024-08-30 A | 2024-09-12 A | 40 | 100% |  |  |  |  |  |  |
| 43 | 4.21.3.4 | Aprobación de Presidencia y MOPT del Cartel | 23d | 2024-09-13 A | 2024-10-15 A | 40, 42 | 100% |  |  |  |  |  |  |
| 44 | 4.21.4 | Preparación Sala de Datos y Requerimientos SICOP | 3d | 2024-10-25 A | 2024-10-29 A | 43 | 100% |  |  |  |  |  |  |
| 45 | 5 | **Fase 2 - Gestión de Contratación y Adjudicación** | 440d | 2024-10-30 A | 2026-07-29 | 39 | 61% | 171.55d | 9d |  |  | 6628h | 3880h |
| 46 | 5.1 | Publicación del Cartel de Licitación (notificación directa a cada uno de los oferentes precalificados) | 1d | 2024-10-30 A | 2024-10-30 A | 39, 44 | 100% |  |  |  | INCOP | 8h | 8h |
| 47 | 5.2 | Recurso de objeción contra el cartel de la licitación (dentro del primer tercio del plazo para presentar ofertas) | 26d | 2024-10-31 A | 2024-12-05 A | 46 | 100% |  |  |  | Contraloría | 208h | 208h |
| 48 | 5.3 | Visita y Sesiones de Pre Oferta | 4d | 2024-11-25 A | 2024-11-28 A |  | 100% |  |  | start no earlier than 2024-11-25 | IFC; INCOP | 64h | 64h |
| 49 | 5.4 | Respuesta de CGR por recurso de objeción | 33d | 2024-12-06 A | 2025-01-21 A | 47 | 100% |  |  |  | Contraloría | 264h | 264h |
| 50 | 5.5 | Periodo de solicitud de modificaciones y aclaraciones al Cartel | 68d | 2024-10-31 | 2025-02-03 | 46 |  |  | 380d |  | IFC; INCOP; Proponentes | 1632h |  |
| 51 | 5.6 | Redacción de solicitud criterio ARESEP por recurso de objeción | 14d | 2025-01-22 A | 2025-02-10 A | 49 | 100% |  |  |  | IFC | 112h | 112h |
| 52 | 5.7 | Solicitud criterio ARESEP por recurso objeción | 2d | 2025-02-10 A | 2025-02-11 A | 51 | 100% |  |  |  | INCOP | 16h | 16h |
| 53 | 5.8 | Respuesta ARESEP Criterio | 10d | 2025-02-12 A | 2025-02-25 A | 52 | 100% |  |  |  | ARESEP | 80h | 80h |
| 54 | 5.9 | Redacción de modificaciones del cartel | 6d | 2025-02-26 A | 2025-03-05 A | 49, 50, 53 | 100% |  |  |  | IFC; INCOP | 96h | 96h |
| 55 | 5.10 | Oficio Hacienda rectificacion Contingencias y VpD | 5d | 2025-03-06 A | 2025-03-12 A | 54 | 100% |  |  |  | Hacienda | 40h | 40h |
| 56 | 5.11 | Aprobación Junta Directiva modificaciones del cartel | 1d | 2025-03-13 A | 2025-03-13 A | 54, 55 | 100% |  |  |  | INCOP | 8h | 8h |
| 57 | 5.12 | Publicación de cartel de licitación (post resolución CGR por recursos de objeción) | 2d | 2025-03-14 A | 2025-03-17 A | 56 | 100% |  |  |  | INCOP | 16h | 16h |
| 58 | 5.13 | Periodo de solicitud de modificaciones y aclaraciones al Cartel | 25d | 2025-03-18 A | 2025-04-21 A | 57 | 100% |  |  |  | IFC; INCOP; Proponentes | 600h | 600h |
| 59 | 5.14 | Segundo recurso de objecion (DP World) | 1d | 2025-04-04 A | 2025-04-04 A |  | 100% |  |  | start no earlier than 2025-04-04 | Proponentes | 8h | 8h |
| 60 | 5.15 | Tercer recurso de objecion | 1d | 2025-04-30 A | 2025-04-30 A |  | 100% |  |  | start no earlier than 2025-04-30 | Proponentes | 8h | 8h |
| 61 | 5.16 | Respuesta CGR 2 y 3 recurso de objecion | 17d | 2025-05-01 A | 2025-05-23 A | 60 | 100% |  |  |  | Contraloría | 136h | 136h |
| 62 | 5.17 | Publicación de cartel de licitación (post resolución CGR por 2 y 3 recurso de objeción) | 22d | 2025-05-26 A | 2025-06-24 A | 61 | 100% |  |  |  | INCOP; IFC | 352h | 352h |
| 63 | 5.18 | Cuarto recurso de objecion | 6d | 2025-06-25 A | 2025-07-02 A | 62 | 100% |  |  |  | Proponentes | 48h | 48h |
| 64 | 5.19 | Respuesta CGR a 4 Recurso de objecion | 22d | 2024-10-30 A | 2025-07-31 A | 63 | 100% |  |  |  | Contraloría | 176h | 176h |
| 65 | 5.20 | Redacción de modificaciones del cartel | 35d | 2025-08-01 A | 2025-09-18 A | 64 | 100% |  |  |  | IFC; INCOP | 560h | 560h |
| 66 | 5.21 | Oficio Hacienda rectificacion Contingencias y VpD y Consulta ARESEP | 15d | 2025-08-01 A | 2025-08-21 A | 64 | 100% |  |  |  | ARESEP; Hacienda; INCOP | 360h | 360h |
| 67 | 5.22 | Aprobación Junta Directiva modificaciones del cartel | 1d | 2025-09-19 A | 2025-09-19 A | 65 | 100% |  |  |  | INCOP | 8h | 8h |
| 68 | 5.23 | Publicación de cartel de licitación (post resolución CGR por recursos de objeción) | 2d | 2025-09-22 A | 2025-09-23 A | 67 | 100% |  |  |  | INCOP | 16h | 16h |
| 69 | 5.24 | Preparación y presentacion de ofertas | 33d | 2025-09-24 | 2025-11-07 | 68 |  |  | 181d |  | Proponentes | 264h |  |
| 70 | 5.25 | Formalización de Comité Evaluador | 30d | 2025-01-22 A | 2025-03-04 A | 49 | 100% |  |  |  | INCOP | 240h | 240h |
| 71 | 5.26 | Evaluación de Ofertas y dictámen de adjudicación | 54d | 2025-11-10 A | 2026-02-13 A | 69 | 100% |  |  |  | Comite Evaluador | 432h | 432h |
| 72 | 5.27 | Apertura oferta económica | 3d | 2026-02-16 A | 2026-02-18 A | 71 | 100% |  |  |  | Comite Evaluador | 24h | 24h |
| 73 | 5.28 | Informe de Recomendación de Oferta Adjudicada | 10d | 2026-02-19 | 2026-03-04 | 71, 72 |  |  | 0d |  | Comite Evaluador | 80h |  |
| 74 | 5.29 | Acto motivado de selección del adjudicatario | 10d | 2026-03-05 | 2026-03-18 | 73 |  |  | 0d |  | INCOP | 80h |  |
| 75 | 5.30 | Publicacion Gaceta | 2d | 2026-03-19 | 2026-03-20 | 74 |  |  | 0d |  |  |  |  |
| 76 | 5.31 | [Contingencia] por recurso de apelación contra acto de licitación | 10d | 2026-03-23 | 2026-04-03 | 74, 75 |  |  | 0d |  | Proponentes | 80h |  |
| 77 | 5.32 | Aprobación de resolucion adjudicación por CGR | 30d | 2026-04-06 | 2026-05-15 | 76 |  |  | 0d |  | Contraloría | 240h |  |
| 78 | 5.33 | Adjudicación | 1d | 2026-05-18 | 2026-05-18 | 77 |  |  | 0d |  | INCOP | 8h |  |

Notes:
- 71: Festivos 24 y 25 diciembre / 31 diciembre y 1 enero

| ID | WBS | Task | Duration | Start | Finish | Predecessors | Complete | Remaining | Total slack | Free slack | Constraint | Resources | Work | Actual work |
| --- | --- | --- | --- | --- | --- | --- | --- | --- | --- | --- | --- | --- | --- | --- |
| 79 | 5.34 | **Formalización Contractual** | 22d | 2026-05-19 | 2026-06-17 | 78 |  |  | 0d |  |  |  | 124h |  |
| 80 | 5.34.1 | Constitución de la Sociedad Concesionaria | 16d | 2026-05-19 | 2026-06-09 | 78 |  |  | 0d |  |  | Adjudicatario [50%] | 64h |  |
| 81 | 5.34.2 | Cumplimiento de condiciones precedentes a la firma, formalización y suscripción | 5d | 2026-06-10 | 2026-06-16 | 80 |  |  | 0d |  |  | Adjudicatario [50%] | 20h |  |
| 82 | 5.34.3 | Firma, formalización y subscripción del Contrato de Concesión | 1d | 2026-06-17 | 2026-06-17 | 81 |  |  | 0d |  |  | Adjudicatario; INCOP; MOPT; Presidencia CR; Hacienda | 40h |  |
| 83 | 5.35 | Refrendo del Contrato de Concesión por CGR | 30d | 2026-06-18 | 2026-07-29 | 82 |  |  | 0d |  |  | Contraloría | 240h |  |
| 84 | 6 | **Prórroga Remolcadores** | 439d | 2024-04-02 A | 2025-12-05 |  | 92% | 33.62d | 161d |  |  |  | 2016h | 1880h |
| 85 | 6.1 | Analisis legal y tecnico del proceso de prorroga | 17d | 2024-04-02 A | 2024-04-24 A |  | 100% |  |  |  | start no earlier than 2024-04-02 | IFC | 136h | 136h |
| 86 | 6.2 | Acreditación del correspondiente interés público de la prórroga con sustento en estudios técnicos que así lo justifiquen | 21d | 2025-03-03 A | 2025-03-31 A |  | 100% |  |  |  | finish no earlier than 2025-03-31 | INCOP | 168h | 168h |
| 87 | 6.3 | Solicitud de aprobación a Junta Directiva para iniciar el proceso de prórroga | 22d | 2025-04-01 A | 2025-04-30 A | 86 | 100% |  |  |  |  | INCOP | 176h | 176h |
| 88 | 6.4 | Redacción de la respectiva adenda al Contrato | 90d | 2025-05-01 A | 2025-09-03 A | 87 | 100% |  |  |  |  | IFC | 720h | 720h |
| 89 | 6.5 | Formalización de la respectiva adenda al Contrato | 30d | 2025-09-04 A | 2025-10-15 A | 88 | 100% |  |  |  |  | INCOP; Concesionarios actuales | 480h | 480h |
| 90 | 6.6 | Refrendo interno de la adenda al contrato y orden de inicio | 42d | 2025-10-09 A | 2025-12-05 | 89 | 60% | 17d | 161d |  |  | Contraloría | 336h | 200h |
| 91 | 7 | **Protocolo de salida concesionario actual** | 378d? | 2025-01-01 | 2026-07-06 |  |  |  |  |  |  |  | 41920h |  |
| 92 | 7.1 | **1. Inventario de activos** | 392d? | 2025-01-01 | 2026-07-24 |  |  |  | 0d |  |  |  | 4528h |  |
| 93 | 7.1.1 | **Evaluar los equipos e infraestructura mediante diagnósticos semestrales, a partir del segundo semestre de 2024, continuando en 2025 y culminando en el primer trimestre de 2026.** | 307d | 2025-01-01 | 2026-03-27 |  |  |  |  |  |  |  | 2584h |  |
| 94 | 7.1.1.1 | Diagnóstico junio 2025 | 129d | 2025-01-01 | 2025-06-30 |  |  |  | 30d | 0d |  | INCOP | 1032h |  |
| 95 | 7.1.1.2 | Diagnóstico diciembre 2025 | 124d | 2025-07-01 | 2025-12-19 | 94 |  |  | 30d | 0d |  | INCOP | 992h |  |
| 96 | 7.1.1.3 | Diagnóstico marzo 2026 | 70d | 2025-12-22 | 2026-04-20 | 95 |  |  | 30d |  |  | INCOP | 560h |  |
| 97 | 7.1.2 | **Inventario final** | 115d? | 2025-09-30 | 2026-03-31 |  |  |  |  |  |  |  | 1224h |  |
| 98 | 7.1.2.1 | Contratación consultor para realizar inventario final y recepcion de bienes | 40d | 2025-09-30 | 2025-11-24 |  |  |  | 6d | 0d |  | INCOP | 320h |  |
| 99 | 7.1.2.2 | Realizar inventario final | 90d | 2025-11-25 | 2026-04-21 | 98 |  |  | 6d | 0d |  | Consultor técnico | 720h |  |
| 100 | 7.1.2.3 | Entrega de inventario final por parte del consultor de INCOP | 1d | 2026-04-22 | 2026-04-22 | 99 |  |  | 6d | 0d |  | Consultor técnico | 8h |  |
| 101 | 7.1.2.4 | INCOP revisión de entrega | 22d | 2026-04-23 | 2026-05-22 | 100 |  |  | 6d | 0d |  | INCOP | 176h |  |
| 102 | 7.1.3 | Redacción del borrador finiquito y acta de recepción de todos los activos según el inventario | 45d | 2026-05-25 | 2026-07-24 | 93, 101 |  |  | 6d | 3d | finish no earlier than 2026-05-29 | Concesionarios actuales; INCOP | 720h |  |

Notes:
- 87: respaldado en los estudios técnicos antes referidos, que sustente el interés público razonado a partir del cual se considera conveniente la prórroga o ampliación del plazo, solicitando al órgano contralor la autorización previa para la materialización de los documentos que formalizarían tal prórroga.)

| ID | WBS | Task | Type | Duration | Start | Finish | Predecessors | Total slack | Free slack | Constraint | Resources | Work |
| --- | --- | --- | --- | --- | --- | --- | --- | --- | --- | --- | --- | --- |
| 103 | 7.2 | **2. Contratos laborales y de subcontratistas** |  | 327d | 2025-03-03 | 2026-06-24 |  | 28d |  |  |  | 3296h |
| 104 | 7.2.1 | INCOP solicitar al concesionario actual el listado de subcontrataciones, proveedores y contratos con terceros vigentes con montos vigentes |  | 66d | 2025-03-03 | 2025-06-02 |  | 28d | 0d | start no earlier than 2025-03-03 | INCOP | 528h |
| 105 | 7.2.2 | Concesionario actual entregar el listado de subcontrataciones, proveedores y terceros vigentes con montos y terminos vigentes certificado por un auditor externo |  | 86d | 2025-06-03 | 2025-09-30 | 104 | 28d | 0d |  | Concesionarios actuales | 688h |
| 106 | 7.2.3 | INCOP revisión de entrega |  | 90d | 2025-10-01 | 2026-02-25 | 105 | 28d | 0d |  | INCOP | 720h |
| 107 | 7.2.4 | Redacción del borrador del finiquito de todos los contratos con terceros y subcontratistas |  | 85d | 2026-02-26 | 2026-06-24 | 106 | 28d | 25d |  | Concesionarios actuales; INCOP | 1360h |
| 108 | 7.3 | **3. Listado de licencias y permisos** |  | 327d | 2025-03-03 | 2026-06-24 |  | 31d |  |  |  | 3296h |
| 109 | 7.3.1 | El INCOP deberá solicitar al concesionario actual un listado de las licencias y permisos vigentes |  | 66d | 2025-03-03 | 2025-06-02 |  | 31d | 0d | start no earlier than 2025-03-03 | INCOP | 528h |
| 110 | 7.3.2 | Concesionario actual entrega un listado de las licencias y permisos vigentes certificado por un auditor externo |  | 86d | 2025-06-03 | 2025-09-30 | 109 | 31d | 0d |  | Concesionarios actuales | 688h |
| 111 | 7.3.3 | INCOP revisión entrega |  | 90d | 2025-10-01 | 2026-02-25 | 110 | 31d | 0d |  | INCOP | 720h |
| 112 | 7.3.4 | Redacción del finiquito de dichos permisos, licencias y autorizaciones certificado |  | 85d | 2026-02-26 | 2026-06-24 | 111 | 31d | 25d | finish no earlier than 2026-05-29 | Concesionarios actuales; INCOP | 1360h |
| 113 | 7.4 | **4. Servicios públicos** |  | 327d | 2025-03-03 | 2026-06-24 |  | 31d |  | start no earlier than 2025-01-01 |  | 3296h |
| 114 | 7.4.1 | El INCOP deberá solicitar al concesionario actual un inventario de los servicios públicos son sus respectivos contratos, facturas, montos vigentes |  | 66d | 2025-03-03 | 2025-06-02 |  | 31d | 0d | start no earlier than 2025-03-03 | INCOP | 528h |
| 115 | 7.4.2 | El concesionario deberá entregar un inventario de los servicios públicos son sus respectivos contratos, facturas, montos vigentes certificado por un auditor externo |  | 86d | 2025-06-03 | 2025-09-30 | 114 | 31d | 0d | start no earlier than 2025-03-03 | Concesionarios actuales | 688h |
| 116 | 7.4.3 | INCOP revisión entrega |  | 90d | 2025-10-01 | 2026-02-25 | 115 | 31d | 0d |  | INCOP | 720h |
| 117 | 7.4.4 | Se deberá redactar el finiquito de dichos servicios que apliquen |  | 85d | 2026-02-26 | 2026-06-24 | 116 | 31d | 25d | finish no earlier than 2026-05-29 | Concesionarios actuales; INCOP | 1360h |
| 118 | 7.5 | **5. Canon** |  | 393d | 2025-01-01 | 2026-07-27 |  | 1d |  |  |  | 6272h |
| 119 | 7.5.1 | Entrega de comprobante de pago de canon conforme facturas recibidas certificadas por un auditor externo | manual | 389d | 2025-01-02 | 2026-07-22 |  |  |  |  | Concesionarios actuales | 3112h |
| 120 | 7.5.2 | Monitoreo de pago de canon conforme facturas recibidas certificadas por un auditor externo |  | 389d | 2025-01-01 | 2026-07-21 |  | 6d | 1d | finish no earlier than 2026-06-30 | INCOP | 3112h |
| 121 | 7.5.3 | Redacción de finiquito borrador de que no hay saldo pendiente del pago de canon a INCOP |  | 3d | 2026-07-23 | 2026-07-27 | 119, 120 | 5d | 2d | start no earlier than 2026-02-17 | Concesionarios actuales; INCOP | 48h |
| 122 | 7.6 | **6. Financiero** |  | 395d | 2025-01-01 | 2026-07-29 |  | 3d |  |  |  | 7568h |
| 123 | 7.6.1 | Entrega de información financiera y modelo financiero actualizado trimestral y anual |  | 390d | 2025-01-01 | 2026-07-22 |  | 3d | 0d |  | Concesionarios actuales | 3120h |
| 124 | 7.6.2 | Revisión de información financiera actualizada y modelo financiero trimestral y anual |  | 390d | 2025-01-01 | 2026-07-22 |  | 3d | 0d |  | INCOP | 3120h |
| 125 | 7.6.3 | INCOP presupuestar y contratar a una firma auditora para que apoye en la revisión del modelo |  | 30d | 2025-12-01 | 2026-02-02 |  | 16d | 0d | start no earlier than 2025-12-01 | INCOP | 240h |
| 126 | 7.6.4 | Revisión demodelo por firma de auditoría |  | 120d | 2026-02-03 | 2026-07-20 | 125 | 16d |  |  | Firma de auditoría | 960h |
| 127 | 7.6.5 | Entrega de modelo financiero actualizado para versión final |  | 3d | 2026-07-23 | 2026-07-27 | 123, 124 | 11d |  |  | Concesionarios actuales; Firma de auditoría | 48h |
| 128 | 7.6.6 | Finiquito borrador de que no existe ninguna obligación de compensación adicional por parte de los concesionarios actuales y el INCOP |  | 5d | 2026-07-23 | 2026-07-29 | 123, 124 | 3d | 0d |  | Concesionarios actuales; INCOP | 80h |

| ID | WBS | Task | Type | Duration | Start | Finish | Predecessors | Total slack | Free slack | Constraint | Resources | Work |
| --- | --- | --- | --- | --- | --- | --- | --- | --- | --- | --- | --- | --- |
| 129 | 7.7 | **7. Ambiental y Social** |  | 342d | 2025-03-03 | 2026-07-15 |  | 16d |  |  |  | 5176h |
| 130 | 7.7.1 | El INCOP deberá solicitar al concesionario actual un inventario de los permisos ambientales |  | 66d | 2025-03-03 | 2025-06-02 |  | 16d | 0d | start no earlier than 2025-03-03 | INCOP | 528h |
| 131 | 7.7.2 | Entrega de inventario de los permisos ambientales | manual | 86d | 2025-06-03 | 2025-09-30 | 130 |  |  |  | Concesionarios actuales | 688h |
| 132 | 7.7.3 | INCOP revisión entrega |  | 45d | 2025-10-01 | 2025-12-02 | 131 | 76d | 0d |  | INCOP | 360h |
| 133 | 7.7.4 | Se deberá redactar finiquito de dichos permisos que apliquen |  | 85d | 2025-12-03 | 2026-04-22 | 132 | 76d | 70d |  | Concesionarios actuales; INCOP | 1360h |
| 134 | 7.7.5 | Acercamiento SETENA para evaluar cierre de garantía ambiental |  | 90d | 2025-10-01 | 2026-02-25 | 131 | 16d | 0d |  | Concesionarios actuales; SETENA | 1440h |
| 135 | 7.7.6 | Borrador para cierre de garantía ambiental del concesionario actual |  | 100d | 2026-02-26 | 2026-07-15 | 134 | 16d | 10d |  | Concesionarios actuales | 800h |
| 136 | 7.8 | **8. Garantías y seguros** |  | 282d | 2025-03-03 | 2026-04-22 |  | 76d |  |  |  | 2256h |
| 137 | 7.8.1 | El INCOP deberá solicitar al concesionario actual un inventario de los seguros y garantías |  | 66d | 2025-03-03 | 2025-06-02 |  | 76d | 0d | start no earlier than 2025-03-03 | INCOP | 528h |
| 138 | 7.8.2 | Entrega inventario seguros y garantias |  | 86d | 2025-06-03 | 2025-09-30 | 137 | 76d | 0d |  | Concesionarios actuales | 688h |
| 139 | 7.8.3 | INCOP revisión entrega |  | 45d | 2025-10-01 | 2025-12-02 | 138 | 76d | 0d |  | INCOP | 360h |
| 140 | 7.8.4 | Borrador para finiquito de cierre de garantías y seguros |  | 85d | 2025-12-03 | 2026-04-22 | 139 | 76d | 70d |  | Concesionarios actuales | 680h |
| 141 | 7.9 | **9. Operativos** |  | 327d | 2025-03-03 | 2026-06-24 |  | 28d |  |  |  | 3296h |
| 142 | 7.9.1 | El INCOP deberá solicitar al concesionario actual los manuales, garantías de equipo e informes de mantenimiento de los equipamientos y en su caso realizar las actualizaciones necesarias |  | 66d | 2025-03-03 | 2025-06-02 |  | 28d | 0d | start no earlier than 2025-03-03 | INCOP | 528h |
| 143 | 7.9.2 | Entrega de los manuales, garantías de equipo e informes de mantenimiento de los equipamientos |  | 86d | 2025-06-03 | 2025-09-30 | 142 | 28d | 0d |  | Concesionarios actuales | 688h |
| 144 | 7.9.3 | INCOP revisión entrega |  | 90d | 2025-10-01 | 2026-02-25 | 143 | 28d | 0d |  | INCOP | 720h |
| 145 | 7.9.4 | Borrador finiquito que no hay entrega pendientes de manuales, garantías de equipo e informes de mantenimiento |  | 85d | 2026-02-26 | 2026-06-24 | 144 | 28d | 25d |  | Concesionarios actuales; INCOP | 1360h |
| 146 | 7.10 | **10. Documentación referente a la infraestructura existente** |  | 282d | 2025-03-03 | 2026-04-22 |  | 73d |  |  |  | 2936h |
| 147 | 7.10.1 | El INCOP deberá solicitar información de los planos finales "As built" |  | 66d | 2025-03-03 | 2025-06-02 |  | 73d | 0d | start no earlier than 2025-03-03 | INCOP | 528h |
| 148 | 7.10.2 | Entrega de los planos |  | 86d | 2025-06-03 | 2025-09-30 | 147 | 73d | 0d |  | Concesionarios actuales | 688h |
| 149 | 7.10.3 | INCOP revisión de entrega |  | 45d | 2025-10-01 | 2025-12-02 | 148 | 73d | 0d |  | INCOP | 360h |
| 150 | 7.10.4 | Borrador finiquito que no hay entrega pendiente de informacion |  | 85d | 2025-12-03 | 2026-04-22 | 149 | 73d | 70d |  | Concesionarios actuales; INCOP | 1360h |
| 151 | 8 | **Etapa de Transición Inicial del Contrato de Concesión** |  | 9d | 2026-07-30 | 2026-08-11 | 83 | 0d |  |  |  | 248h |
| 152 | 8.1 | Formalización y Entrega Finiquito de las concesiones previas de los concesionarios previos |  | 5d | 2026-07-30 | 2026-08-05 | 83, 102, 107, 121, 128, 145, 150 | 3d |  |  | Concesionarios actuales; INCOP | 80h |
| 153 | 8.2 | Culminar el cierre y apertura de permisos y servicios públicos al nuevo concesionario |  | 2d | 2026-07-30 | 2026-07-31 | 83, 112, 117, 133 | 6d |  |  | Concesionarios actuales; INCOP | 32h |
| 154 | 8.3 | Cierre y apertura de garantías |  | 2d | 2026-07-30 | 2026-07-31 | 135, 140 | 6d |  |  | Concesionarios actuales; INCOP | 32h |
| 155 | 8.4 | Redacción orden de inicio y acta de inicio de la concesión |  | 8d | 2026-07-30 | 2026-08-10 | 83 | 0d |  |  | INCOP | 64h |
| 156 | 8.5 | Formalización del Acta de recepción de las Concesiones Previas |  | 1d | 2026-08-11 | 2026-08-11 | 152, 153, 154, 155 | 0d |  |  | Nuevo concesionario; INCOP; Concesionarios actuales | 24h |
| 157 | 8.6 | Orden de Inicio y Acta de Inicio de la Concesión |  | 1d | 2026-08-11 | 2026-08-11 | 156SS | 0d |  |  | Nuevo concesionario; INCOP | 16h |

Notes:
- 151: La Etapa de Transición Inicial iniciará en la fecha establecida en la Notificación de Refrendo del Contrato de la Concesión y terminará en la Fecha de Entrada en Vigencia
