# Puerto_Caldera_IFC_INCOP v8

Schedule from MS Project, 2023-05-22 to 2026-08-11, A marks actual dates.

## Calendars

- Standard: Mon-Fri 08:00-12:00, 13:00-17:00; Sat-Sun off.

## Resources

| Resource |
| --- |
| Proponentes |
| IFC |
| INCOP |
| MIDEPLAN |
| Contraloría |
| Comite Evaluador |
| Adjudicatario |
| MOPT |
| Hacienda |
| Presidencia CR |
| Consultor |
| Consultor técnico |
| Concesionarios actuales |
| SETENA |
| Firma de auditoría |
| Nuevo concesionario |
| ARESEP |

## Schedule

| ID | WBS | Task | Duration | Start | Finish | Predecessors | Complete | Remaining | Total slack | Constraint | Resources | Work | Actual work |
| --- | --- | --- | --- | --- | --- | --- | --- | --- | --- | --- | --- | --- | --- |
| 1 | 1 | Inicio | 1d | 2023-05-31 | 2023-05-31 |  |  |  | 834d |  |  |  |  |
| 2 | 2 | Refrendo del Contrato de Servicios de Asesoría Transaccional por la CGR | 1d | 2023-05-22 A | 2023-05-22 A |  | 100% |  |  | must start on 2023-05-22 |  |  |  |
| 3 | 3 | **Contratación Consultores de la CFI** | 20d | 2023-05-31 A | 2023-06-27 A |  | 100% |  |  |  |  |  |  |
| 4 | 3.1 | Técnico | 8d | 2023-05-31 A | 2023-06-09 A |  | 100% |  |  |  |  |  |  |
| 5 | 3.2 | Ambiental y Social | 11d | 2023-05-31 A | 2023-06-14 A |  | 100% |  |  |  |  |  |  |
| 6 | 3.3 | Legal | 20d | 2023-05-31 A | 2023-06-27 A |  | 100% |  |  |  |  |  |  |
| 7 | 3.4 | Comunicación | 20d | 2023-05-31 A | 2023-06-27 A |  | 100% |  |  |  |  |  |  |
| 8 | 3.5 | Costo Beneficio, Riesgos y Valor por dinero | 20d | 2023-05-31 A | 2023-06-27 A |  | 100% |  |  |  |  |  |  |
| 9 | 4 | **Fase 1 - Preinversión, Inversión y Cartel** | 362d | 2023-06-12 A | 2024-10-29 |  | 96% | 15.37d | 465d |  |  | 1488h | 1488h |
| 10 | 4.1 | Reunión inicial: Plan de Trabajo | 3d | 2023-06-14 A | 2023-06-16 A |  | 100% |  |  | start no earlier than 2023-06-14 |  |  |  |
| 11 | 4.2 | Consultas comité para socialización del Proyecto (MIDEPLAN, MOPT, ARESEP, SETENA) | 3d | 2023-06-14 A | 2023-06-16 A |  | 100% |  |  | start no earlier than 2023-06-14 |  |  |  |
| 12 | 4.3 | Entrega del Plan de Trabajo (honorario 1) | 1d | 2023-06-14 A | 2023-06-14 A |  | 100% |  |  | start no earlier than 2023-06-14 | IFC | 8h | 8h |
| 13 | 4.4 | Debida diligencia Legal | 97d | 2023-06-28 A | 2023-11-09 A | 6 | 100% |  |  | start no earlier than 2023-06-20 |  |  |  |
| 14 | 4.5 | Debida Diligencia Técnica, de Mercado y Análisis Tarifario | 109d | 2023-06-12 A | 2023-11-09 A | 4 | 100% |  |  | start no earlier than 2023-06-01 |  |  |  |
| 15 | 4.6 | Debida Diligencia Socio-Ambiental | 106d | 2023-06-15 A | 2023-11-09 A | 5 | 100% |  |  | start no earlier than 2023-06-06 |  |  |  |
| 16 | 4.7 | Debida Diligencia Financiera | 97d | 2023-06-19 A | 2023-10-31 A | 10 | 100% |  |  | start no earlier than 2023-06-19 |  |  |  |
| 17 | 4.8 | Sondeo de mercado | 10d | 2023-10-02 A | 2023-10-13 A |  | 100% |  |  | finish no earlier than 2023-10-13 |  |  |  |
| 18 | 4.9 | Plan de Comunicaciones | 98d | 2023-06-28 A | 2023-11-10 A | 7 | 100% |  |  | finish no earlier than 2023-10-31 |  |  |  |
| 19 | 4.10 | Entrega de los Estudios de Debida Diligencia Legal (Honorario 2 ) | 1d | 2023-11-10 A | 2023-11-10 A | 13 | 100% |  |  |  | IFC | 8h | 8h |
| 20 | 4.11 | Entrega de los estudios de Debida Diligencia Técnica y Socio-Ambiental (Honorario 3) | 1d | 2023-11-10 A | 2023-11-10 A | 14 | 100% |  |  |  | IFC | 8h | 8h |
| 21 | 4.12 | Preparación del Informe de Prefactibilidad | 13d | 2023-11-13 A | 2023-11-29 A | 20 | 100% |  |  | start no earlier than 2023-10-02 |  |  |  |
| 22 | 4.13 | Entrega del Informe de Prefactibilidad (Honorario 4) | 1d | 2023-11-30 A | 2023-11-30 A | 21 | 100% |  |  |  | IFC | 8h | 8h |
| 23 | 4.14 | Aprobación de INCOP del Informe de Prefactibilidad | 19d | 2024-01-04 A | 2024-01-30 A | 22 | 100% |  |  | finish no earlier than 2024-01-30 | INCOP | 152h | 152h |
| 24 | 4.15 | Aprobación de la Secretaría de Planeación Sectorial del MOPT y de MIDEPLAN del Informe de Prefactibilidad | 65d | 2024-01-31 A | 2024-04-30 A | 23 | 100% |  |  | finish no earlier than 2024-04-30 | MIDEPLAN | 520h | 520h |
| 25 | 4.16 | Preparación del Informe de Factibilidad | 58d | 2024-05-01 A | 2024-07-19 A | 24 | 100% |  |  |  |  |  |  |
| 26 | 4.17 | Entrega del Informe de Factibilidad (Honorario 5) | 1d | 2024-07-22 A | 2024-07-22 A | 25 | 100% |  |  |  | IFC | 8h | 8h |
| 27 | 4.18 | Aprobación de INCOP del Informe de Factibilidad | 32d | 2024-07-23 A | 2024-09-04 A | 26 | 100% |  |  |  | INCOP | 256h | 256h |
| 28 | 4.19 | Aprobación de la Secretaría de Planeación Sectorial del MOPT y de MIDEPLAN del Informe de Factibilidad | 3d | 2024-09-05 A | 2024-09-09 A | 27 | 100% |  |  |  | MIDEPLAN | 24h | 24h |

| ID | WBS | Task | Duration | Start | Finish | Predecessors | Complete | Remaining | Total slack | Constraint | Resources | Work | Actual work |
| --- | --- | --- | --- | --- | --- | --- | --- | --- | --- | --- | --- | --- | --- |
| 29 | 4.20 | **Proceso de Requerimientos Comision Evaluadora y Criterios de Admisibilidad** | 63d | 2024-01-31 A | 2024-04-26 |  | 59% | 25.54d | 597d |  |  | 32h | 32h |
| 30 | 4.20.1 | Redacción de Requerimientos de Legales, Técnicos y Financieros para Expresiones de Interés | 17d | 2024-01-31 A | 2024-02-22 A | 23 | 100% |  |  |  |  |  |  |
| 31 | 4.20.2 | Entrega de Requerimientos de Legales, Técnicos y Financieros (Honorario 6) | 1d | 2024-02-23 A | 2024-02-23 A | 30 | 100% |  |  |  | IFC | 8h | 8h |
| 32 | 4.20.3 | Aprobación de INCOP Criterios de Admisibilidad | 2d | 2024-02-26 A | 2024-02-27 A | 31 | 100% |  |  |  | INCOP | 16h | 16h |
| 33 | 4.20.4 | Entrega de Requerimientos de Comision Evaluadora | 1d | 2024-02-23 A | 2024-02-23 A | 30 | 100% |  |  |  | INCOP | 8h | 8h |
| 34 | 4.20.5 | Formación Comité Evaluador | 45d | 2024-02-26 | 2024-04-26 | 31 |  |  | 597d |  |  |  |  |
| 35 | 4.20.6 | Sondeo de Mercado con espectro de potenciales interesados | 45d | 2024-02-26 A | 2024-04-26 A | 31 | 100% |  |  |  |  |  |  |
| 36 | 4.21 | **Cartel de Licitación y Contrato de Concesión** | 195d | 2024-01-31 A | 2024-10-29 A |  | 100% |  |  |  |  | 464h | 464h |
| 37 | 4.21.1 | Redacción Cartel de Licitación y Contrato de Concesión | 136d | 2024-01-31 A | 2024-08-07 A | 23 | 100% |  |  |  |  |  |  |
| 38 | 4.21.2 | Entrega Cartel de Licitación y Contrato de Concesión (Honorario 7) | 1d | 2024-08-08 A | 2024-08-08 A | 37 | 100% |  |  |  | IFC | 8h | 8h |
| 39 | 4.21.3 | **Proceso de aprobacion para la publicación del Cartel de Licitación** | 57d | 2024-08-09 A | 2024-10-28 A | 38 | 100% |  |  |  |  | 456h | 456h |
| 40 | 4.21.3.1 | Aprobación por la junta directiva de INCOP | 57d | 2024-08-09 A | 2024-10-28 A | 38 | 100% |  |  |  | INCOP | 456h | 456h |
| 41 | 4.21.3.2 | Aprobación de Ministerio de Ambiente sobre requerimientos de estudios ambientales en el Cartel | 1d | 2024-09-06 A | 2024-09-06 A | 40 | 100% |  |  |  |  |  |  |
| 42 | 4.21.3.3 | Aprobación de ARESEP de la estructura tarifaria y los parámetros de ajuste | 10d | 2024-08-30 A | 2024-09-12 A | 40 | 100% |  |  |  |  |  |  |
| 43 | 4.21.3.4 | Aprobación de Presidencia y MOPT del Cartel | 23d | 2024-09-13 A | 2024-10-15 A | 40, 42 | 100% |  |  |  |  |  |  |
| 44 | 4.21.4 | Preparación Sala de Datos y Requerimientos SICOP | 3d | 2024-10-25 A | 2024-10-29 A | 43 | 100% |  |  |  |  |  |  |
| 45 | 5 | **Fase 2 - Gestión de Contratación y Adjudicación** | 440d | 2024-10-30 A | 2026-07-07 | 39 | 18% | 362.75d | 25d |  |  | 5652h | 896h |
| 46 | 5.1 | Publicación del Cartel de Licitación (notificación directa a cada uno de los oferentes precalificados) | 1d | 2024-10-30 A | 2024-10-30 A | 39, 44 | 100% |  |  |  | INCOP | 8h | 8h |
| 47 | 5.2 | Recurso de objeción contra el cartel de la licitación (dentro del primer tercio del plazo para presentar ofertas) | 26d | 2024-10-31 A | 2024-12-05 A | 46 | 100% |  |  |  | Contraloría | 208h | 208h |
| 48 | 5.3 | Visita y Sesiones de Pre Oferta | 4d | 2024-11-25 A | 2024-11-28 A |  | 100% |  |  | start no earlier than 2024-11-25 | IFC; INCOP | 64h | 64h |
| 49 | 5.4 | Respuesta de CGR por recurso de objeción | 33d | 2024-12-06 A | 2025-01-21 A | 47 | 100% |  |  |  | Contraloría | 264h | 264h |
| 50 | 5.5 | Periodo de solicitud de modificaciones y aclaraciones al Cartel | 68d | 2024-10-31 | 2025-02-03 | 46 |  |  | 396d |  | IFC; INCOP; Proponentes | 1632h |  |
| 51 | 5.6 | Redacción de solicitud criterio ARESEP por recurso de objeción | 14d | 2025-01-22 A | 2025-02-10 A | 49 | 100% |  |  |  | IFC | 112h | 112h |
| 52 | 5.7 | Solicitud criterio ARESEP por recurso objeción | 2d | 2025-02-10 A | 2025-02-11 A | 51 | 100% |  |  |  | INCOP | 16h | 16h |
| 53 | 5.8 | Respuesta ARESEP Criterio | 10d | 2025-02-12 A | 2025-02-25 A | 52 | 100% |  |  |  | ARESEP | 80h | 80h |
| 54 | 5.9 | Redacción de modificaciones del cartel | 6d | 2025-02-26 A | 2025-03-05 A | 49, 50, 53 | 100% |  |  |  | IFC; INCOP | 96h | 96h |
| 55 | 5.10 | Oficio Hacienda rectificacion Contingencias y VpD | 5d | 2025-03-06 A | 2025-03-12 A | 54 | 100% |  |  |  | Hacienda | 40h | 40h |
| 56 | 5.11 | Aprobación Junta Directiva modificaciones del cartel | 1d | 2025-03-13 A | 2025-03-13 A | 54, 55 | 100% |  |  |  | INCOP | 8h | 8h |
| 57 | 5.12 | Publicación de cartel de licitación (post resolución CGR por recursos de objeción) | 2d | 2025-03-14 | 2025-03-17 | 56 |  |  | 0d |  | INCOP | 16h |  |
| 58 | 5.13 | Periodo de recurso de objecion | 12d | 2025-03-18 | 2025-04-02 | 57 |  |  | 354d |  | Proponentes | 96h |  |
| 59 | 5.14 | Periodo de solicitud de modificaciones y aclaraciones al Cartel | 25d | 2025-03-18 | 2025-04-21 | 57 |  |  | 341d |  | IFC; INCOP; Proponentes | 600h |  |
| 60 | 5.15 | Preparación de ofertas | 45d | 2025-03-18 | 2025-05-19 | 57 |  |  | 0d |  |  |  |  |
| 61 | 5.16 | Formalización de Comité Evaluador | 30d | 2025-01-22 | 2025-03-04 | 49 |  |  | 375d |  | INCOP | 240h |  |
| 62 | 5.17 | Evaluación de Ofertas y dictámen de adjudicación (plazo de subsanación 5 días) | 45d | 2025-05-20 | 2025-07-21 | 60 |  |  | 0d |  | Comite Evaluador | 360h |  |
| 63 | 5.18 | Apertura oferta económica | 1d | 2025-07-22 | 2025-07-22 | 62 |  |  | 275d |  | Comite Evaluador | 8h |  |
| 64 | 5.19 | Informe de Recomendación de Oferta Adjudicada | 10d | 2025-07-22 | 2025-08-04 | 62 |  |  | 0d |  | Comite Evaluador | 80h |  |
| 65 | 5.20 | Acto motivado de selección del adjudicatario | 10d | 2025-08-05 | 2025-08-18 | 64 |  |  | 0d |  | INCOP | 80h |  |
| 66 | 5.21 | [Contingencia] por recurso de apelación contra acto de licitación | 5d | 2025-08-19 | 2025-08-25 | 65 |  |  | 0d |  | Proponentes | 40h |  |
| 67 | 5.22 | Aprobación de resolucion adjudicación por CGR | 45d | 2025-08-26 | 2025-10-27 | 66 |  |  | 0d |  | Contraloría | 360h |  |
| 68 | 5.23 | Adjudicación | 1d | 2025-10-28 | 2025-10-28 | 67 |  |  | 0d |  | INCOP | 8h |  |

| ID | WBS | Task | Duration | Start | Finish | Predecessors | Complete | Remaining | Total slack | Free slack | Constraint | Resources | Work | Actual work |
| --- | --- | --- | --- | --- | --- | --- | --- | --- | --- | --- | --- | --- | --- | --- |
| 69 | 5.24 | **Formalización Contractual** | 60d | 2025-10-29 | 2026-01-20 | 68 |  |  | 0d |  |  |  | 276h |  |
| 70 | 5.24.1 | Constitución de la Sociedad Concesionaria | 45d | 2025-10-29 | 2025-12-30 | 68 |  |  | 0d |  |  | Adjudicatario [50%] | 180h |  |
| 71 | 5.24.2 | Cumplimiento de condiciones precedentes a la firma, formalización y suscripción | 14d | 2025-12-31 | 2026-01-19 | 70 |  |  | 0d |  |  | Adjudicatario [50%] | 56h |  |
| 72 | 5.24.3 | Firma, formalización y subscripción del Contrato de Concesión | 1d | 2026-01-20 | 2026-01-20 | 71 |  |  | 0d |  |  | Adjudicatario; INCOP; MOPT; Presidencia CR; Hacienda | 40h |  |
| 73 | 5.25 | Refrendo del Contrato de Concesión por CGR (Alcance del Contrato IFC) | 120d | 2026-01-21 | 2026-07-07 | 72 |  |  | 0d |  |  | Contraloría | 960h |  |
| 74 | 6 | **Prórroga Remolcadores** | 437d | 2024-04-02 A | 2025-12-03 |  | 8% | 402.45d | 179d |  |  |  | 1896h | 136h |
| 75 | 6.1 | Analisis legal y tecnico del proceso de prorroga | 17d | 2024-04-02 A | 2024-04-24 A |  | 100% |  |  |  | start no earlier than 2024-04-02 | IFC | 136h | 136h |
| 76 | 6.2 | Acreditación del correspondiente interés público de la prórroga con sustento en estudios técnicos que así lo justifiquen | 21d | 2025-03-03 | 2025-03-31 |  |  |  | 179d | 0d | finish no earlier than 2025-03-31 | INCOP | 168h |  |
| 77 | 6.3 | Solicitud de aprobación a Junta Directiva para iniciar el proceso de prórroga | 22d | 2025-04-01 | 2025-04-30 | 76 |  |  | 179d | 0d |  | INCOP | 176h |  |
| 78 | 6.4 | Redacción de la respectiva adenda al Contrato | 43d | 2025-05-01 | 2025-06-30 | 77 |  |  | 179d | 0d |  | IFC | 344h |  |
| 79 | 6.5 | Formalización de la respectiva adenda al Contrato | 22d | 2025-07-01 | 2025-07-30 | 78 |  |  | 179d | 0d |  | INCOP; Concesionarios actuales | 352h |  |
| 80 | 6.6 | Refrendo contralor de la adenda al contrato | 90d | 2025-07-31 | 2025-12-03 | 79 |  |  | 179d |  |  | Contraloría | 720h |  |
| 81 | 7 | **Protocolo de salida concesionario actual** | 394d? | 2025-01-01 | 2026-07-06 |  |  |  |  |  |  |  | 39920h |  |
| 82 | 7.1 | **1. Inventario de activos** | 392d? | 2025-01-01 | 2026-07-02 |  |  |  | 0d |  |  |  | 4528h |  |
| 83 | 7.1.1 | **Evaluar los equipos e infraestructura mediante diagnósticos semestrales, a partir del segundo semestre de 2024, continuando en 2025 y culminando en el primer trimestre de 2026.** | 323d | 2025-01-01 | 2026-03-27 |  |  |  |  |  |  |  | 2584h |  |
| 84 | 7.1.1.1 | Diagnóstico junio 2025 | 129d | 2025-01-01 | 2025-06-30 |  |  |  | 27d | 0d |  | INCOP | 1032h |  |
| 85 | 7.1.1.2 | Diagnóstico diciembre 2025 | 124d | 2025-07-01 | 2025-12-19 | 84 |  |  | 27d | 0d |  | INCOP | 992h |  |
| 86 | 7.1.1.3 | Diagnóstico marzo 2026 | 70d | 2025-12-22 | 2026-03-27 | 85 |  |  | 27d |  |  | INCOP | 560h |  |
| 87 | 7.1.2 | **Inventario final** | 131d? | 2025-09-30 | 2026-03-31 |  |  |  |  |  |  |  | 1224h |  |
| 88 | 7.1.2.1 | Contratación consultor para realizar inventario final y recepcion de bienes | 40d | 2025-09-30 | 2025-11-24 |  |  |  | 3d | 0d |  | INCOP | 320h |  |
| 89 | 7.1.2.2 | Realizar inventario final | 90d | 2025-11-25 | 2026-03-30 | 88 |  |  | 3d | 0d |  | Consultor técnico | 720h |  |
| 90 | 7.1.2.3 | Entrega de inventario final por parte del consultor de INCOP | 1d | 2026-03-31 | 2026-03-31 | 89 |  |  | 3d | 0d |  | Consultor técnico | 8h |  |
| 91 | 7.1.2.4 | INCOP revisión de entrega | 22d | 2026-04-01 | 2026-04-30 | 90 |  |  | 3d | 0d |  | INCOP | 176h |  |
| 92 | 7.1.3 | Redacción del borrador finiquito y acta de recepción de todos los activos según el inventario | 45d | 2026-05-01 | 2026-07-02 | 83, 91 |  |  | 3d |  | finish no earlier than 2026-05-29 | Concesionarios actuales; INCOP | 720h |  |

Notes:
- 77: respaldado en los estudios técnicos antes referidos, que sustente el interés público razonado a partir del cual se considera conveniente la prórroga o ampliación del plazo, solicitando al órgano contralor la autorización previa para la materialización de los documentos que formalizarían tal prórroga.)

| ID | WBS | Task | Type | Duration | Start | Finish | Predecessors | Total slack | Free slack | Constraint | Resources | Work |
| --- | --- | --- | --- | --- | --- | --- | --- | --- | --- | --- | --- | --- |
| 93 | 7.2 | **2. Contratos laborales y de subcontratistas** |  | 282d | 2025-03-03 | 2026-03-31 |  | 70d |  |  |  | 2936h |
| 94 | 7.2.1 | INCOP solicitar al concesionario actual el listado de subcontrataciones, proveedores y contratos con terceros vigentes con montos vigentes |  | 66d | 2025-03-03 | 2025-06-02 |  | 70d | 0d | start no earlier than 2025-03-03 | INCOP | 528h |
| 95 | 7.2.2 | Concesionario actual entregar el listado de subcontrataciones, proveedores y terceros vigentes con montos y terminos vigentes certificado por un auditor externo |  | 86d | 2025-06-03 | 2025-09-30 | 94 | 70d | 0d |  | Concesionarios actuales | 688h |
| 96 | 7.2.3 | INCOP revisión de entrega |  | 45d | 2025-10-01 | 2025-12-02 | 95 | 70d | 0d |  | INCOP | 360h |
| 97 | 7.2.4 | Redacción del borrador del finiquito de todos los contratos con terceros y subcontratistas |  | 85d | 2025-12-03 | 2026-03-31 | 96 | 70d |  |  | Concesionarios actuales; INCOP | 1360h |
| 98 | 7.3 | **3. Listado de licencias y permisos** |  | 325d | 2025-03-03 | 2026-05-29 |  | 27d |  |  |  | 2936h |
| 99 | 7.3.1 | El INCOP deberá solicitar al concesionario actual un listado de las licencias y permisos vigentes |  | 66d | 2025-03-03 | 2025-06-02 |  | 70d | 0d | start no earlier than 2025-03-03 | INCOP | 528h |
| 100 | 7.3.2 | Concesionario actual entrega un listado de las licencias y permisos vigentes certificado por un auditor externo |  | 86d | 2025-06-03 | 2025-09-30 | 99 | 70d | 0d |  | Concesionarios actuales | 688h |
| 101 | 7.3.3 | INCOP revisión entrega |  | 45d | 2025-10-01 | 2025-12-02 | 100 | 70d | 43d |  | INCOP | 360h |
| 102 | 7.3.4 | Redacción del finiquito de dichos permisos, licencias y autorizaciones certificado |  | 85d | 2026-02-02 | 2026-05-29 | 101 | 27d |  | finish no earlier than 2026-05-29 | Concesionarios actuales; INCOP | 1360h |
| 103 | 7.4 | **4. Servicios públicos** |  | 325d | 2025-03-03 | 2026-05-29 |  | 27d |  | start no earlier than 2025-01-01 |  | 2936h |
| 104 | 7.4.1 | El INCOP deberá solicitar al concesionario actual un inventario de los servicios públicos son sus respectivos contratos, facturas, montos vigentes |  | 66d | 2025-03-03 | 2025-06-02 |  | 70d | 0d | start no earlier than 2025-03-03 | INCOP | 528h |
| 105 | 7.4.2 | El concesionario deberá entregar un inventario de los servicios públicos son sus respectivos contratos, facturas, montos vigentes certificado por un auditor externo |  | 86d | 2025-06-03 | 2025-09-30 | 104 | 70d | 0d | start no earlier than 2025-03-03 | Concesionarios actuales | 688h |
| 106 | 7.4.3 | INCOP revisión entrega |  | 45d | 2025-10-01 | 2025-12-02 | 105 | 70d | 43d |  | INCOP | 360h |
| 107 | 7.4.4 | Se deberá redactar el finiquito de dichos servicios que apliquen |  | 85d | 2026-02-02 | 2026-05-29 | 106 | 27d |  | finish no earlier than 2026-05-29 | Concesionarios actuales; INCOP | 1360h |
| 108 | 7.5 | **5. Canon** |  | 392d | 2025-01-02 | 2026-07-03 |  | 0d |  |  |  | 6272h |
| 109 | 7.5.1 | Entrega de comprobante de pago de canon conforme facturas recibidas certificadas por un auditor externo | manual | 389d | 2025-01-02 | 2026-06-30 |  |  |  |  | Concesionarios actuales | 3112h |
| 110 | 7.5.2 | Monitoreo de pago de canon conforme facturas recibidas certificadas por un auditor externo |  | 389d | 2025-01-02 | 2026-06-30 |  | 2d | 0d | finish no earlier than 2026-06-30 | INCOP | 3112h |
| 111 | 7.5.3 | Redacción de finiquito borrador de que no hay saldo pendiente del pago de canon a INCOP |  | 3d | 2026-07-01 | 2026-07-03 | 109, 110 | 2d |  | start no earlier than 2026-02-17 | Concesionarios actuales; INCOP | 48h |
| 112 | 7.6 | **6. Financiero** |  | 395d | 2025-01-01 | 2026-07-07 |  | 0d |  |  |  | 7568h |
| 113 | 7.6.1 | Entrega de información financiera y modelo financiero actualizado trimestral y anual |  | 390d | 2025-01-01 | 2026-06-30 |  | 0d |  |  | Concesionarios actuales | 3120h |
| 114 | 7.6.2 | Revisión de información financiera actualizada y modelo financiero trimestral y anual |  | 390d | 2025-01-01 | 2026-06-30 |  | 0d |  |  | INCOP | 3120h |
| 115 | 7.6.3 | INCOP presupuestar y contratar a una firma auditora para que apoye en la revisión del modelo |  | 30d | 2025-12-01 | 2026-01-09 |  | 32d | 0d | start no earlier than 2025-12-01 | INCOP | 240h |
| 116 | 7.6.4 | Revisión demodelo por firma de auditoría |  | 120d | 2026-01-12 | 2026-06-26 | 115 | 32d |  |  | Firma de auditoría | 960h |
| 117 | 7.6.5 | Entrega de modelo financiero actualizado para versión final |  | 3d | 2026-07-01 | 2026-07-03 | 113, 114 | 27d |  |  | Concesionarios actuales; Firma de auditoría | 48h |
| 118 | 7.6.6 | Finiquito borrador de que no existe ninguna obligación de compensación adicional por parte de los concesionarios actuales y el INCOP |  | 5d | 2026-07-01 | 2026-07-07 | 113, 114 | 0d |  |  | Concesionarios actuales; INCOP | 80h |

| ID | WBS | Task | Type | Duration | Start | Finish | Predecessors | Total slack | Free slack | Constraint | Resources | Work |
| --- | --- | --- | --- | --- | --- | --- | --- | --- | --- | --- | --- | --- |
| 119 | 7.7 | **7. Ambiental y Social** |  | 317d | 2025-03-03 | 2026-05-19 |  | 35d |  |  |  | 4616h |
| 120 | 7.7.1 | El INCOP deberá solicitar al concesionario actual un inventario de los permisos ambientales |  | 66d | 2025-03-03 | 2025-06-02 |  | 35d | 0d | start no earlier than 2025-03-03 | INCOP | 528h |
| 121 | 7.7.2 | Entrega de inventario de los permisos ambientales | manual | 86d | 2025-06-03 | 2025-09-30 | 120 |  |  |  | Concesionarios actuales | 688h |
| 122 | 7.7.3 | INCOP revisión entrega |  | 45d | 2025-10-01 | 2025-12-02 | 121 | 70d | 0d |  | INCOP | 360h |
| 123 | 7.7.4 | Se deberá redactar finiquito de dichos permisos que apliquen |  | 85d | 2025-12-03 | 2026-03-31 | 122 | 70d |  |  | Concesionarios actuales; INCOP | 1360h |
| 124 | 7.7.5 | Acercamiento SETENA para evaluar cierre de garantía ambiental |  | 45d | 2025-10-01 | 2025-12-02 | 121 | 35d | 0d |  | Concesionarios actuales; SETENA | 720h |
| 125 | 7.7.6 | Borrador para cierre de garantía ambiental del concesionario actual |  | 120d | 2025-12-03 | 2026-05-19 | 124 | 35d |  |  | Concesionarios actuales | 960h |
| 126 | 7.8 | **8. Garantías y seguros** |  | 282d | 2025-03-03 | 2026-03-31 |  | 70d |  |  |  | 2256h |
| 127 | 7.8.1 | El INCOP deberá solicitar al concesionario actual un inventario de los seguros y garantías |  | 66d | 2025-03-03 | 2025-06-02 |  | 70d | 0d | start no earlier than 2025-03-03 | INCOP | 528h |
| 128 | 7.8.2 | Entrega inventario seguros y garantias |  | 86d | 2025-06-03 | 2025-09-30 | 127 | 70d | 0d |  | Concesionarios actuales | 688h |
| 129 | 7.8.3 | INCOP revisión entrega |  | 45d | 2025-10-01 | 2025-12-02 | 128 | 70d | 0d |  | INCOP | 360h |
| 130 | 7.8.4 | Borrador para finiquito de cierre de garantías y seguros |  | 85d | 2025-12-03 | 2026-03-31 | 129 | 70d |  |  | Concesionarios actuales | 680h |
| 131 | 7.9 | **9. Operativos** |  | 282d | 2025-03-03 | 2026-03-31 |  | 70d |  |  |  | 2936h |
| 132 | 7.9.1 | El INCOP deberá solicitar al concesionario actual los manuales, garantías de equipo e informes de mantenimiento de los equipamientos y en su caso realizar las actualizaciones necesarias |  | 66d | 2025-03-03 | 2025-06-02 |  | 70d | 0d | start no earlier than 2025-03-03 | INCOP | 528h |
| 133 | 7.9.2 | Entrega de los manuales, garantías de equipo e informes de mantenimiento de los equipamientos |  | 86d | 2025-06-03 | 2025-09-30 | 132 | 70d | 0d |  | Concesionarios actuales | 688h |
| 134 | 7.9.3 | INCOP revisión entrega |  | 45d | 2025-10-01 | 2025-12-02 | 133 | 70d | 0d |  | INCOP | 360h |
| 135 | 7.9.4 | Borrador finiquito que no hay entrega pendientes de manuales, garantías de equipo e informes de mantenimiento |  | 85d | 2025-12-03 | 2026-03-31 | 134 | 70d |  |  | Concesionarios actuales; INCOP | 1360h |
| 136 | 7.10 | **10. Documentación referente a la infraestructura existente** |  | 282d | 2025-03-03 | 2026-03-31 |  | 70d |  |  |  | 2936h |
| 137 | 7.10.1 | El INCOP deberá solicitar información de los planos finales "As built" |  | 66d | 2025-03-03 | 2025-06-02 |  | 70d | 0d | start no earlier than 2025-03-03 | INCOP | 528h |
| 138 | 7.10.2 | Entrega de los planos |  | 86d | 2025-06-03 | 2025-09-30 | 137 | 70d | 0d |  | Concesionarios actuales | 688h |
| 139 | 7.10.3 | INCOP revisión de entrega |  | 45d | 2025-10-01 | 2025-12-02 | 138 | 70d | 0d |  | INCOP | 360h |
| 140 | 7.10.4 | Borrador finiquito que no hay entrega pendiente de informacion |  | 85d | 2025-12-03 | 2026-03-31 | 139 | 70d |  |  | Concesionarios actuales; INCOP | 1360h |
| 141 | 8 | **Etapa de Transición Inicial del Contrato de Concesión** |  | 25d | 2026-07-08 | 2026-08-11 | 73 | 0d |  |  |  | 1384h |
| 142 | 8.1 | Formalización y Entrega Finiquito de las concesiones previas de los concesionarios previos |  | 24d | 2026-07-08 | 2026-08-10 | 73, 92, 97, 111, 118, 135, 140 | 0d |  |  | Concesionarios actuales; INCOP | 384h |
| 143 | 8.2 | Culminar el cierre y apertura de permisos y servicios públicos al nuevo concesionario |  | 24d | 2026-07-08 | 2026-08-10 | 73, 102, 107, 123 | 0d |  |  | Concesionarios actuales; INCOP | 384h |
| 144 | 8.3 | Cierre y apertura de garantías |  | 24d | 2026-07-08 | 2026-08-10 | 125, 130 | 0d |  |  | Concesionarios actuales; INCOP | 384h |
| 145 | 8.4 | Redacción orden de inicio y acta de inicio de la concesión |  | 24d | 2026-07-08 | 2026-08-10 | 73 | 0d |  |  | INCOP | 192h |
| 146 | 8.5 | Formalización del Acta de recepción de las Concesiones Previas |  | 1d | 2026-08-11 | 2026-08-11 | 142, 143, 144, 145 | 0d |  |  | Nuevo concesionario; INCOP; Concesionarios actuales | 24h |
| 147 | 8.6 | Orden de Inicio y Acta de Inicio de la Concesión |  | 1d | 2026-08-11 | 2026-08-11 | 146SS | 0d |  |  | Nuevo concesionario; INCOP | 16h |

Notes:
- 141: La Etapa de Transición Inicial iniciará en la fecha establecida en la Notificación de Refrendo del Contrato de la Concesión y terminará en la Fecha de Entrada en Vigencia
